# Project OBRA - BAYER ARGENTINA

Schedule from MS Project, 2017-05-02 to 2017-12-29, status date 2017-05-22, A marks actual dates.
contract

## Calendars

- Estándar: Mon-Fri 09:00-13:00, 15:00-19:00; Sat 08:00-12:00, 13:00-17:00; Sun off.

## Schedule

| ID | WBS | Task | Type | Duration | Start | Finish | Predecessors | Complete | Remaining | Total slack | Free slack | Constraint |
| --- | --- | --- | --- | --- | --- | --- | --- | --- | --- | --- | --- | --- |
| 1 | 1 | **OBRA BAYER ARGENTINA** |  | 208d | 2017-05-02 A | 2017-12-29 |  | 6% | 195.1d | 0d |  |  |
| 2 | 1.1 | **ETAPA 1** |  | 51d | 2017-05-02 A | 2017-06-29 |  | 13% | 44.2d | 157d |  |  |
| 3 | 1.1.1 | Inicio | milestone | 1d | 2017-05-02 A | 2017-05-02 A |  | 100% |  |  |  | start no earlier than 2017-05-02 |
| 4 | 1.1.2 | desmonte de equipamiento existente |  | 11d | 2017-05-03 A | 2017-05-15 A | 3 | 100% |  |  |  |  |
| 5 | 1.1.3 | Retiro de equipamiento existente | milestone | 2d | 2017-05-23 | 2017-05-24 | 4FS+6d |  |  | 164d | 0d |  |
| 6 | 1.1.4 | Armado de estructura de Durlock |  | 5d | 2017-05-19 A | 2017-05-24 | 5FS-5d | 60% | 2d | 173d | 0d |  |
| 7 | 1.1.5 | Emplaque 1 cara |  | 4d | 2017-05-22 A | 2017-05-25 | 6FS-3d | 25% | 3d | 179d | 0d |  |
| 8 | 1.1.6 | Movimiento de cajas ackerman |  | 5d | 2017-05-25 | 2017-05-30 | 5 |  |  | 177d | 0d |  |
| 9 | 1.1.7 | Cableado electrico |  | 4d | 2017-05-31 | 2017-06-05 | 8 |  |  | 178.88d |  |  |
| 10 | 1.1.8 | Cableado estructurado |  | 4d | 2017-05-31 | 2017-06-03 | 8 |  |  | 177d | 0d |  |
| 11 | 1.1.9 | Instalación electrica tabiques durlock |  | 2d | 2017-05-26 | 2017-05-27 | 7 |  |  | 179d | 0d |  |
| 12 | 1.1.10 | Nivelación de piso tecnico y cierre |  | 2d | 2017-06-05 | 2017-06-06 | 10 |  |  | 177d |  |  |
| 13 | 1.1.11 | Colocación de segunda placa tabiques |  | 2d | 2017-05-29 | 2017-05-30 | 11 |  |  | 179d | 0d |  |
| 14 | 1.1.12 | Replanteo Fauna tarimas y bancadas | milestone | 1d | 2017-05-25 | 2017-05-25 | 6 |  |  | 173d | 0d |  |
| 15 | 1.1.13 | Montaje de tarimas y bancadas |  | 4d | 2017-06-07 | 2017-06-10 | 14FS+10d, 13 |  |  | 173d |  |  |
| 16 | 1.1.14 | Armado de estructura cielorrasos |  | 4d | 2017-05-30 | 2017-06-02 | 17 |  |  | 180d |  |  |
| 17 | 1.1.15 | Desarme cielorraso de chapa |  | 2d | 2017-05-25 | 2017-05-29 | 5 |  |  | 164d | 0d |  |
| 18 | 1.1.16 | Medición tachos AA |  | 1d | 2017-05-31 | 2017-05-31 | 17FS+1d |  |  | 164d | 0d |  |
| 19 | 1.1.17 | Colocación de conductos |  | 7d | 2017-06-09 | 2017-06-16 | 18FS+7d |  |  | 164d | 0d |  |
| 20 | 1.1.18 | Montaje evaporadoras y cajas |  | 3d | 2017-06-17 | 2017-06-20 | 19 |  |  | 164d | 0d |  |
| 21 | 1.1.19 | Instalación equipos con cañerías |  | 1d | 2017-06-21 | 2017-06-21 | 20 |  |  | 164d |  |  |
| 22 | 1.1.20 | Bandejas y cañerías para iluminación y baja tensión |  | 4d | 2017-05-31 | 2017-06-03 | 17FS+1d |  |  | 175d | 0d |  |
| 23 | 1.1.21 | Cableado electrico |  | 3d | 2017-06-05 | 2017-06-07 | 22 |  |  | 176d |  |  |
| 24 | 1.1.22 | Cableado baja tensíon |  | 2d | 2017-06-05 | 2017-06-06 | 22 |  |  | 175d | 0d |  |
| 25 | 1.1.23 | Cierre de cielorraso de chapa |  | 2d | 2017-06-07 | 2017-06-08 | 24 |  |  | 175d |  |  |
| 26 | 1.1.24 | Instalación de paneles de vidrio y puerta sala de reunion chica |  | 3d | 2017-05-26 | 2017-05-29 | 3FS+20d |  |  | 184d |  |  |
| 27 | 1.1.25 | Instalación de revestimientos Fauna |  | 3d | 2017-06-03 | 2017-06-06 | 14FS+7d |  |  | 177d |  |  |
| 28 | 1.1.26 | Revestimiento patagonia Entrega |  | 1d | 2017-05-31 | 2017-05-31 | 13 |  |  | 182d |  |  |
| 29 | 1.1.27 | Armado de sala de reunion grande |  | 5d | 2017-06-07 | 2017-06-12 | 3FS+30d |  |  | 0d |  |  |
| 30 | 1.1.28 | Entrega de frentes vidriados sala de reunión grande |  | 2d | 2017-06-13 | 2017-06-14 | 29 |  |  | 168d | 0d |  |
| 31 | 1.1.29 | Colocación de alfombra modular existente |  | 7d | 2017-06-07 | 2017-06-14 | 29FS-5d |  |  | 0d |  |  |
| 32 | 1.1.30 | Entrega de mobiliario de Interieur Forma | milestone | 1d | 2017-06-12 | 2017-06-12 | 31FS-3d |  |  | 0d |  |  |
| 33 | 1.1.31 | Armado de muebles de linea |  | 5d | 2017-06-13 | 2017-06-17 | 32 |  |  | 0d |  |  |
| 34 | 1.1.32 | Instalación eletrica de muebles de linea |  | 5d | 2017-06-16 | 2017-06-21 | 33FS-2d |  |  | 164d |  |  |
| 35 | 1.1.33 | Colocación de grafica |  | 2d | 2017-06-15 | 2017-06-16 | 30 |  |  | 168d |  |  |
| 36 | 1.1.34 | Limpieza final |  | 10d | 2017-06-19 | 2017-06-29 | 33 |  |  | 0d |  |  |

| ID | WBS | Task | Type | Duration | Start | Finish | Predecessors | Total slack | Constraint |
| --- | --- | --- | --- | --- | --- | --- | --- | --- | --- |
| 37 | 1.2 | **ETAPA 2** |  | 47d | 2017-07-18 | 2017-09-09 |  | 0d |  |
| 38 | 1.2.1 | Inicio | milestone | 1d | 2017-07-18 | 2017-07-18 | 36FS+15d | 0d |  |
| 39 | 1.2.2 | Desmonte del equipamiento existente |  | 12d | 2017-07-19 | 2017-08-01 | 38 | 0d |  |
| 40 | 1.2.3 | Retiro de equipamiento existente | milestone | 2d | 2017-08-02 | 2017-08-03 | 39 | 0d | finish no earlier than 2016-05-02 |
| 41 | 1.2.4 | obra |  | 32d | 2017-08-04 | 2017-09-09 | 40 | 0d | finish no earlier than 2016-05-09 |
| 42 | 1.3 | **ETAPA 3** |  | 47d | 2017-09-19 | 2017-11-11 |  | 0d |  |
| 43 | 1.3.1 | Inicio | milestone | 1d | 2017-09-19 | 2017-09-19 | 41FS+7d | 0d | start no earlier than 2016-05-10 |
| 44 | 1.3.2 | desmonte de equipamiento existente |  | 12d | 2017-09-20 | 2017-10-03 | 43 | 0d | finish no earlier than 2016-05-02 |
| 45 | 1.3.3 | Retiro del equipamiento existente |  | 2d | 2017-10-04 | 2017-10-05 | 44 | 0d |  |
| 46 | 1.3.4 | obra |  | 32d | 2017-10-06 | 2017-11-11 | 45 | 0d | finish no earlier than 2016-06-07 |
| 47 | 1.4 | **ETAPA 4** |  | 41d | 2017-11-13 | 2017-12-29 |  | 0d |  |
| 48 | 1.4.1 | Inicio | milestone | 1d | 2017-11-13 | 2017-11-13 | 42 | 0d | finish no earlier than 2016-06-24 |
| 49 | 1.4.2 | desmonte de equipamiento existente |  | 3d | 2017-11-14 | 2017-11-16 | 48 | 0d |  |
| 50 | 1.4.3 | obra |  | 40d | 2017-11-14 | 2017-12-29 | 49SS | 0d |  |
